# CSF Upgrades and Migrations

Schedule from MS Project, 2013-01-14 to 2013-06-14, A marks actual dates.
MIT

## Calendars

- Standard: Mon-Fri 08:00-12:00, 13:00-17:00; Sat-Sun off.

## Resources

| Resource |
| --- |
| Dave |
| René |
| Steve |
| Felicia |
| Ram |
| Kevin |
| Brian |
| Janet |
| Seth |
| Lee |
| Faith |
| Peter |
| Debra |

## Schedule

| ID | WBS | Task | Type | Duration | Start | Finish | Predecessors | Complete | Remaining | Baseline start | Baseline finish | Baseline duration | Total slack | Free slack | Resources | Work | Actual work |
| --- | --- | --- | --- | --- | --- | --- | --- | --- | --- | --- | --- | --- | --- | --- | --- | --- | --- |
| 1 | 1 | Upgrade CSF to 2.0 |  | 10d | 2013-01-14 A | 2013-01-25 A |  | 100% |  |  |  |  |  |  |  |  |  |
| 2 | 2 | **Upgrade of Existing CSF Apps to CSF 2.0** |  | 40d? | 2013-01-14 A | 2013-03-08 |  | 29% | 28.29d? | 2013-02-13 | 2013-03-08 | 18d? | 70d |  |  | 157.6h | 48h |
| 3 | 2.1 | **Development** |  | 18d | 2013-02-13 A | 2013-03-08 |  | 60% | 7.2d | 2013-02-13 | 2013-03-08 | 18d | 70d |  |  | 80h | 48h |
| 4 | 2.1.1 | Upgrade IAP |  | 7d | 2013-02-14 A | 2013-02-25 A | 1FS+13d | 100% |  | 2013-02-14 | 2013-02-20 | 4d |  |  | Steve [50%] | 28h | 28h |
| 5 | 2.1.2 | Upgrade Subject Evaluation Report/OSE Report |  | 1d | 2013-02-26 A | 2013-02-26 A | 4FS+3d | 100% |  | 2013-02-26 | 2013-03-01 | 4d |  |  | Steve [50%] | 4h | 4h |
| 6 | 2.1.3 | Upgrade Sponsor Billing |  | 4d | 2013-02-13 A | 2013-02-19 A | 1FS+12d | 100% |  | 2013-02-13 | 2013-02-19 | 4d |  |  | Dave [50%] | 16h | 16h |
| 7 | 2.1.4 | Upgrade Survey Engine |  | 4d | 2013-02-26 | 2013-03-01 | 6FS+4d |  |  | 2013-02-26 | 2013-03-01 | 4d | 55d | 0d | Dave [50%] | 16h |  |
| 8 | 2.1.5 | Upgrade Response Rate Report |  | 4d | 2013-03-05 | 2013-03-08 | 7FS+1d |  |  | 2013-03-05 | 2013-03-08 | 4d | 55d | 0d | Dave [50%] | 16h |  |
| 9 | 2.1.6 | Upgrades complete | milestone | 0d | 2013-03-08 | 2013-03-08 | 4, 5, 6, 7, 8 |  |  | 2013-03-08 | 2013-03-08 | 0d | 56d |  | Dave [50%]; Steve [50%] |  |  |
| 10 | 2.2 | **Testing** |  | 39d? | 2013-01-14 | 2013-03-07 |  |  |  |  |  |  | 71d |  |  | 53.6h |  |
| 11 | 2.2.1 | **Test Planning** |  | 8d | 2013-02-20 | 2013-03-01 |  |  |  |  |  |  | 71d |  |  | 31.6h |  |
| 12 | 2.2.1.1 | IAP and Sponsor Billing |  | 3d | 2013-02-20 | 2013-02-22 | 4SS+4d |  |  |  |  |  | 62d | 0d | Seth [25%]; Faith [25%] | 7.6h |  |
| 13 | 2.2.1.2 | OSE Applications |  | 3d | 2013-02-27 | 2013-03-01 | 12FS+2d |  |  |  |  |  | 59d | 0d | Lee | 24h |  |
| 14 | 2.2.1.3 | Test Planning Complete | milestone | 0d | 2013-03-01 | 2013-03-01 | 12, 13 |  |  |  |  |  | 60d | 1d |  |  |  |
| 15 | 2.2.2 | **BA Testing** |  | 9d? | 2013-02-25 | 2013-03-07 |  |  |  |  |  |  | 71d |  |  | 22h |  |
| 16 | 2.2.2.1 | Sponsor Billing |  | 3d | 2013-02-25 | 2013-02-27 | 12 |  |  |  |  |  | 56d | 0d | Faith [25%] | 6h |  |
| 17 | 2.2.2.2 | IAP |  | 4d | 2013-03-04 | 2013-03-07 | 16FS+2d |  |  |  |  |  | 56d |  | Seth [25%] | 8h |  |
| 18 | 2.2.2.3 | OSE Applications |  | 1d? | 2013-03-04 | 2013-03-04 | 13 |  |  |  |  |  | 59d | 0d | Lee | 8h |  |
| 19 | 2.2.2.4 | BA Testing Complete | milestone | 0d | 2013-03-04 | 2013-03-04 | 16, 18 |  |  |  |  |  | 73d | 0d |  |  |  |
| 20 | 2.2.3 | **UAT** |  | 1d? | 2013-01-14 | 2013-01-14 |  |  |  |  |  |  | 108d |  |  |  |  |
| 21 | 2.2.3.1 | Upgrade Subject Evaluation Report/OSE Report |  | 1d? | 2013-01-14 | 2013-01-14 |  |  |  |  |  |  | 94d | 0d |  |  |  |
| 22 | 2.2.3.2 | Survey Engine |  | 1d? | 2013-01-14 | 2013-01-14 |  |  |  |  |  |  | 94d | 0d |  |  |  |
| 23 | 2.2.3.3 | Upgrade Response Rate Report |  | 1d? | 2013-01-14 | 2013-01-14 |  |  |  |  |  |  | 94d | 0d |  |  |  |
| 24 | 2.2.3.4 | UAT Complete | milestone | 0d | 2013-01-14 | 2013-01-14 | 21, 22, 23 |  |  |  |  |  | 108d | 35d |  |  |  |
| 25 | 2.2.4 | Testing Efforts Complete |  | 1d? | 2013-03-05 | 2013-03-05 | 14, 19, 24 |  |  |  |  |  | 59d |  |  |  |  |

| ID | WBS | Task | Type | Duration | Start | Finish | Predecessors | Complete | Remaining | Baseline start | Baseline finish | Baseline duration | Total slack | Free slack | Resources | Work | Actual work |
| --- | --- | --- | --- | --- | --- | --- | --- | --- | --- | --- | --- | --- | --- | --- | --- | --- | --- |
| 26 | 2.3 | **Deployment Preparation** |  | 1d? | 2013-01-14 | 2013-01-14 |  |  |  |  |  |  | 109d |  |  | 24h |  |
| 27 | 2.3.1 | Create deployment plan |  | 1d? | 2013-01-14 | 2013-01-14 |  |  |  |  |  |  | 94d |  | René | 8h |  |
| 28 | 2.3.2 | Review deployment plan with participants |  | 1d? | 2013-01-14 | 2013-01-14 |  |  |  |  |  |  | 94d |  | René | 8h |  |
| 29 | 2.3.3 | Create registration support plan |  | 1d? | 2013-01-14 | 2013-01-14 |  |  |  |  |  |  | 94d |  | René | 8h |  |
| 30 | 2.4 | **Go-live** |  | 39d | 2013-01-14 | 2013-03-07 |  |  |  |  |  |  | 71d |  |  |  |  |
| 31 | 2.4.1 | Sponsor Billing | milestone | 0d | 2013-03-01 | 2013-03-01 | 16FS+2d |  |  |  |  |  | 61d | 4d |  |  |  |
| 32 | 2.4.2 | IAP | milestone | 0d | 2013-03-07 | 2013-03-07 | 17 |  |  |  |  |  | 57d | 0d |  |  |  |
| 33 | 2.4.3 | OSE Applications | milestone | 0d | 2013-01-14 | 2013-01-14 |  |  |  |  |  |  | 96d | 39d |  |  |  |
| 34 | 2.5 | Upgrade of Existing CSF Apps to CSF 2.0 Complete | milestone | 0d | 2013-03-07 | 2013-03-07 | 31, 32, 33 |  |  |  |  |  | 57d |  |  |  |  |
| 35 | 3 | **Convert SAIS-Common Apps to CSF 2.0** |  | 1d? | 2013-01-14 | 2013-01-14 |  |  |  |  |  |  | 109d |  |  |  |  |
| 36 | 3.1 | Development |  | 1d? | 2013-01-14 | 2013-01-14 |  |  |  |  |  |  | 95d |  |  |  |  |
| 37 | 3.2 | Testing |  | 1d? | 2013-01-14 | 2013-01-14 |  |  |  |  |  |  | 95d |  |  |  |  |
| 38 | 4 | **PE REG Upgrade** |  | 57d? | 2013-01-14 A | 2013-04-02 |  | 9% | 51.72d? | 2013-02-07 | 2013-03-07 | 21d? | 53d |  |  | 272h | 40h |
| 39 | 4.1 | **Phase I - Java 6, Touchstone, and CSF Enabling** |  | 39d? | 2013-02-07 A | 2013-04-02 |  | 10% | 35.02d? | 2013-02-07 | 2013-03-07 | 21d? | 53d |  |  | 256h | 40h |
| 40 | 4.1.1 | **Development** |  | 27d | 2013-02-07 A | 2013-03-15 |  | 19% | 21.81d | 2013-02-07 | 2013-03-07 | 21d | 53d |  |  | 208h | 40h |
| 41 | 4.1.1.1 | Do set-up and configuration required for upgrade |  | 5d | 2013-02-07 A | 2013-02-13 A |  | 100% |  | 2013-02-07 | 2013-02-13 | 5d |  |  | Ram | 40h | 40h |
| 42 | 4.1.1.2 | Perform upgrade |  | 7d | 2013-02-14 A | 2013-02-25 | 41 |  | 7d | 2013-02-14 | 2013-02-21 | 5d | 52d | 0d | Ram | 56h |  |
| 43 | 4.1.1.3 | Unit test changes |  | 14d | 2013-02-26 | 2013-03-15 | 42 |  |  | 2013-02-22 | 2013-03-07 | 10d | 39d | 0d | Ram | 112h |  |
| 44 | 4.1.2 | **Testing** |  | 29d? | 2013-02-20 | 2013-04-01 |  |  |  |  |  |  | 54d |  |  | 48h |  |
| 45 | 4.1.2.1 | Test planning |  | 12d | 2013-02-20 | 2013-03-07 | 42SS+4d |  |  |  |  |  | 45d | 6d | Debra [25%] | 24h |  |
| 46 | 4.1.2.2 | QA testing |  | 5d | 2013-03-18 | 2013-03-22 | 45, 43 |  |  |  |  |  | 39d | 0d | Debra [25%] | 10h |  |
| 47 | 4.1.2.3 | QA bug fix testing |  | 3d | 2013-03-25 | 2013-03-27 | 46 |  |  |  |  |  | 39d | 0d | Debra [25%] | 6h |  |
| 48 | 4.1.2.4 | Load testing |  | 1d? | 2013-03-28 | 2013-03-28 | 47 |  |  |  |  |  | 41d |  | Ram | 8h |  |
| 49 | 4.1.2.5 | User testing |  | 1d? | 2013-04-01 | 2013-04-01 | 47FS+2d |  |  |  |  |  | 39d | 0d |  |  |  |
| 50 | 4.1.3 | Go-live |  | 1d? | 2013-04-02 | 2013-04-02 | 49 |  |  |  |  |  | 39d | 0d |  |  |  |

| ID | WBS | Task | Type | Duration | Start | Finish | Predecessors | Complete | Remaining | Baseline start | Baseline finish | Baseline duration | Total slack | Free slack | Constraint | Resources | Work | Actual work |
| --- | --- | --- | --- | --- | --- | --- | --- | --- | --- | --- | --- | --- | --- | --- | --- | --- | --- | --- |
| 51 | 4.2 | **Phase II - Full CSF Upgrade** |  | 47d? | 2013-01-14 | 2013-03-19 |  |  |  |  |  |  | 63d |  |  |  | 16h |  |
| 52 | 4.2.1 | **Development** |  | 2d? | 2013-03-18 | 2013-03-19 |  |  |  |  |  |  | 63d |  |  |  | 16h |  |
| 53 | 4.2.1.1 | Perform full upgrade |  | 1d? | 2013-03-18 | 2013-03-18 | 43 |  |  |  |  |  | 48d | 0d |  | Ram | 8h |  |
| 54 | 4.2.1.2 | Unit test changes |  | 1d? | 2013-03-19 | 2013-03-19 | 53 |  |  |  |  |  | 48d |  |  | Ram | 8h |  |
| 55 | 4.2.2 | **Testing** |  | 1d? | 2013-01-14 | 2013-01-14 |  |  |  |  |  |  | 109d |  |  |  |  |  |
| 56 | 4.2.2.1 | QA |  | 1d? | 2013-01-14 | 2013-01-14 |  |  |  |  |  |  | 95d |  |  |  |  |  |
| 57 | 4.2.2.2 | User |  | 1d? | 2013-01-14 | 2013-01-14 |  |  |  |  |  |  | 95d |  |  |  |  |  |
| 58 | 4.2.3 | Go-live |  | 1d? | 2013-01-14 | 2013-01-14 |  |  |  |  |  |  | 95d | 56d |  |  |  |  |
| 59 | 4.3 | PE REG upgrade complete | milestone | 0d | 2013-04-02 | 2013-04-02 | 50, 58 |  |  |  |  |  | 39d |  |  | Ram |  |  |
| 60 | 5 | **OREG to Conversion to CSF 2.0** |  | 90d | 2013-02-11 A | 2013-06-14 |  | 13% | 78.51d | 2013-02-11 | 2013-05-28 | 76d | 0d |  |  |  | 662h | 96h |
| 61 | 5.1 | **Development (including unit testing)** |  | 35d | 2013-02-11 A | 2013-03-29 |  | 35% | 22.65d | 2013-02-11 | 2013-03-22 | 29d | 17d | 0d |  |  | 272h | 96h |
| 62 | 5.1.1 | Phase 1 - Required as-is , high priority (A/D and OREG) |  | 9d | 2013-02-11 A | 2013-02-22 A |  | 100% |  |  |  |  |  |  | start no earlier than 2013-02-11 | Felicia | 72h | 72h |
| 63 | 5.1.2 | Phase 2 - Medium priority validation and messaging |  | 15d | 2013-02-25 A | 2013-03-15 | 62 | 20% | 12d |  |  |  | 16d | 0d |  | Felicia | 120h | 24h |
| 64 | 5.1.3 | Phase 3 - Stabilize JAR and rafactor CSF dependencies |  | 5d | 2013-03-18 | 2013-03-22 | 63 |  |  |  |  |  | 16d | 0d |  | Felicia | 40h |  |
| 65 | 5.1.4 | Phase 4 - Modify OREG to use new JAR and upgrade to CSF 2.0 |  | 5d | 2013-03-25 | 2013-03-29 | 64 |  |  |  |  |  | 17d | 0d |  | Felicia | 40h |  |
| 66 | 5.1.5 | OREG conversion development complete | milestone | 0d | 2013-03-29 | 2013-03-29 | 65 |  |  |  |  |  | 17d | 0d |  | Felicia |  |  |
| 67 | 5.2 | Regression Testing |  | 24d | 2013-04-01 | 2013-05-03 | 66 |  |  | 2013-03-25 | 2013-04-26 | 24d | 17d | 0d |  | Kevin | 192h |  |
| 68 | 5.3 | UAT |  | 15d | 2013-04-29 | 2013-05-17 | 67FS-5d |  |  | 2013-04-29 | 2013-05-24 | 20d | 17d | 0d |  | Peter [25%] | 30h |  |
| 69 | 5.4 | **Deployment Preparation** |  | 11d | 2013-04-29 | 2013-05-13 |  |  |  |  |  |  | 24d |  |  |  | 88h |  |
| 70 | 5.4.1 | Create deployment plan |  | 5d | 2013-04-29 | 2013-05-03 | 68SS |  |  |  |  |  | 24d | 0d |  | René | 40h |  |
| 71 | 5.4.2 | Review deployment plan with participants |  | 1d | 2013-05-06 | 2013-05-06 | 70 |  |  |  |  |  | 24d | 0d |  | René | 8h |  |
| 72 | 5.4.3 | Create registration support plan |  | 5d | 2013-05-07 | 2013-05-13 | 71 |  |  |  |  |  | 24d |  |  | René | 40h |  |
| 73 | 5.5 | Go-live | milestone | 0d | 2013-05-21 | 2013-05-21 | 68FS+2d |  |  | 2013-05-28 | 2013-05-28 | 0d | 18d | 0d |  | René |  |  |
| 74 | 5.6 | Prod smoke test | milestone | 0d | 2013-05-21 | 2013-05-21 | 73 |  |  |  |  |  | 18d |  |  | Peter |  |  |
| 75 | 5.7 | Registration opens | milestone | 0d | 2013-06-03 | 2013-06-03 |  |  |  |  |  |  | 0d |  | start no earlier than 2013-06-03 | Peter |  |  |
| 76 | 5.8 | Registration support |  | 10d | 2013-06-03 | 2013-06-14 | 75 |  |  |  |  |  | 0d |  |  | René | 80h |  |

| ID | WBS | Task | Type | Duration | Start | Finish | Predecessors | Remaining | Total slack | Free slack | Constraint | Resources | Work |
| --- | --- | --- | --- | --- | --- | --- | --- | --- | --- | --- | --- | --- | --- |
| 77 | 6 | **Notes Utility Beta** |  | 80d? | 2013-02-25 A | 2013-06-14 |  | 80d? | 0d |  |  |  | 374h |
| 78 | 6.1 | **Functional Specs** |  | 3d? | 2013-02-25 A | 2013-02-27 |  | 3d? | 40d |  |  |  | 24h |
| 79 | 6.1.1 | Write functional specs |  | 1d? | 2013-02-25 A | 2013-02-25 |  | 1d? | 40d | 0d |  | Seth | 8h |
| 80 | 6.1.2 | Have team review of functional specs |  | 1d? | 2013-02-26 | 2013-02-26 | 79 |  | 40d | 0d |  | Seth | 8h |
| 81 | 6.1.3 | Get sponsor approval of specs |  | 1d? | 2013-02-27 | 2013-02-27 | 80 |  | 40d | 0d |  | Seth | 8h |
| 82 | 6.1.4 | Functional specs complete | milestone | 0d | 2013-02-27 | 2013-02-27 | 81 |  | 40d | 22d |  | Seth |  |
| 83 | 6.2 | Development |  | 19d | 2013-04-01 | 2013-04-26 | 61, 82 |  | 17d | 0d |  | Felicia | 152h |
| 84 | 6.3 | UAT |  | 15d | 2013-04-29 | 2013-05-17 | 83 |  | 17d | 0d |  | Peter [25%] | 30h |
| 85 | 6.4 | **Deployment Preparation** |  | 11d | 2013-04-29 | 2013-05-13 |  |  | 24d |  |  |  | 88h |
| 86 | 6.4.1 | Create deployment plan |  | 5d | 2013-04-29 | 2013-05-03 | 70SS |  | 24d | 0d |  | René | 40h |
| 87 | 6.4.2 | Review deployment plan with participants |  | 1d | 2013-05-06 | 2013-05-06 | 86 |  | 24d | 0d |  | René | 8h |
| 88 | 6.4.3 | Create registration support plan |  | 5d | 2013-05-07 | 2013-05-13 | 87 |  | 24d |  |  | René | 40h |
| 89 | 6.5 | Go-live | milestone | 0d | 2013-05-21 | 2013-05-21 | 84FS+2d |  | 18d | 0d |  | René |  |
| 90 | 6.6 | Prod smoke test | milestone | 0d | 2013-05-21 | 2013-05-21 | 89 |  | 18d |  |  | Peter |  |
| 91 | 6.7 | Registration opens | milestone | 0d | 2013-06-03 | 2013-06-03 |  |  | 0d |  | start no earlier than 2013-06-03 | Peter |  |
| 92 | 6.8 | Registration support |  | 10d | 2013-06-03 | 2013-06-14 | 91 |  | 0d |  |  | René | 80h |
