# Java 1.4 to Java 6 Upgrades

Schedule from MS Project, 2014-05-19 to 2014-06-17, A marks actual dates.
Microsoft

## Calendars

- MIT Calendar: Mon-Fri 08:00-12:00, 13:00-17:00; Sat-Sun off. Exceptions (off unless hours are given): 2014-05-26 (Holiday).

## Resources

| Resource |
| --- |
| René Little |
| Steve Turner |
| Paul Cronin |
| Ben Cole |
| Kirsten Derrickson-Boice |
| Felicia Leung |
| Alan Cohen |
| Andrea Collins |
| Dave Tanner |
| Brian Canavan |
| Melissa Martin-Green |
| Steve Pepper |
| Lee Leffler |
| Brendon Puffer |
| Darson Technologies |
| Lynne Hogan |

## Schedule

| ID | WBS | Task | Type | Duration | Start | Finish | Predecessors | Complete | Remaining | Baseline start | Baseline finish | Baseline duration | Total slack | Free slack | Resources | Work | Actual work |
| --- | --- | --- | --- | --- | --- | --- | --- | --- | --- | --- | --- | --- | --- | --- | --- | --- | --- |
| 1 | 1 | **Web Grad Aid** |  | 21d? | 2014-05-19 A | 2014-06-17 |  | 91% | 1.95d? | 2014-05-19 | 2014-06-17 | 21d? | 0d |  |  | 335.79h | 311.79h |
| 2 | 1.1 | **Development** |  | 21d | 2014-05-19 A | 2014-06-17 |  | 96% | 0.74d | 2014-05-19 | 2014-06-17 | 21d | 0d |  |  | 335.79h | 311.79h |
| 3 | 1.1.1 | Move all files compatible to Maven project | manual | 14d | 2014-05-19 A | 2014-06-06 A |  | 100% |  | 2014-05-19 | 2014-06-06 | 14d |  |  | Darson Technologies | 20h | 20h |
| 4 | 1.1.2 | Remove EJB related functionality | manual | 10d | 2014-05-21 A | 2014-06-04 A | 3SS+2d | 100% |  | 2014-05-21 | 2014-06-04 | 10d |  |  | Darson Technologies | 20h | 20h |
| 5 | 1.1.3 | Create service layer | manual | 3d | 2014-05-23 A | 2014-05-28 A | 4SS+2d | 100% |  | 2014-05-23 | 2014-05-28 | 3d |  |  | Darson Technologies | 20h | 20h |
| 6 | 1.1.4 | Change DAO layer | manual | 7d | 2014-05-29 A | 2014-06-06 A | 5 | 100% |  | 2014-05-29 | 2014-06-10 | 9d |  |  | Darson Technologies | 23.33h | 23.33h |
| 7 | 1.1.5 | Execute unit test cases | manual | 7d | 2014-06-03 A | 2014-06-11 A | 6SS+3d | 100% |  | 2014-06-03 | 2014-06-06 | 4d |  |  | Darson Technologies | 54h | 54h |
| 8 | 1.1.6 | Implement Touch stone | manual | 12d | 2014-05-21 A | 2014-06-06 A | 4SS | 100% |  | 2014-05-21 | 2014-06-09 | 13d |  |  | Darson Technologies | 18.46h | 18.46h |
| 9 | 1.1.7 | Prepare design document | manual | 5d | 2014-06-04 A | 2014-06-10 | 8FS-4d | 80% | 1d | 2014-06-04 | 2014-06-10 | 5d |  |  | Darson Technologies | 40h | 32h |
| 10 | 1.1.8 | Prepare Project setup document | manual | 2d | 2014-06-11 A | 2014-06-12 A | 9 | 100% |  | 2014-06-11 | 2014-06-12 | 2d |  |  | Darson Technologies | 10h | 10h |
| 11 | 1.1.9 | Test Cases for existing application including databases | manual | 10d | 2014-05-21 A | 2014-06-04 A | 8SS | 100% |  | 2014-05-21 | 2014-06-04 | 10d |  |  | Darson Technologies | 50h | 50h |
| 12 | 1.1.10 | Application unit testing | manual | 9d | 2014-06-05 A | 2014-06-17 | 11 | 80% | 1.8d | 2014-06-05 | 2014-06-17 | 9d |  |  | Darson Technologies | 80h | 64h |
| 13 | 1.2 | Test Planning |  | 1d? | 2014-05-19 | 2014-05-19 |  |  |  |  |  |  | 20d |  |  |  |  |
| 14 | 1.3 | BA Testing and Bug fixing |  | 1d? | 2014-05-19 | 2014-05-19 |  |  |  |  |  |  | 20d |  |  |  |  |
| 15 | 1.4 | User Testing and Bug fixing |  | 1d? | 2014-05-19 | 2014-05-19 |  |  |  |  |  |  | 20d |  |  |  |  |
| 16 | 1.5 | Deployment Preparation |  | 1d? | 2014-05-19 | 2014-05-19 |  |  |  |  |  |  | 20d |  |  |  |  |
| 17 | 1.6 | Go-live |  | 1d? | 2014-05-19 | 2014-05-19 |  |  |  |  |  |  | 20d | 0d |  |  |  |
| 18 | 1.7 | Web Grad Aid Upgrade Complete | milestone | 0d | 2014-05-19 | 2014-05-19 | 17 |  |  |  |  |  | 20d |  |  |  |  |
| 19 | 2 | UROP |  | 1d? | 2014-05-19 | 2014-05-19 |  |  |  |  |  |  | 20d |  |  |  |  |
