# Java_Apps_Upgrades_Project_Plan

Schedule from MS Project, 2013-10-21 to 2014-06-05, A marks actual dates.
Microsoft

## Calendars

- Standard: Mon-Fri 08:00-12:00, 13:00-17:00; Sat-Sun off.

## Resources

| Resource | Group |
| --- | --- |
| René Little | PM |
| Steve Turner | Arch |
| Paul Cronin | OPS |
| Ben Cole | Support |
| Kirsten Derrickson-Boice | BA |
| Felicia Leung |  |
| Consultant Developer | DEV |
| Jim Frederick | BA |
| Alan Cohen | BA |
| Andrea Collins | BA |
| Dave Tanner | Arch |
| Brian Canavan | Business |
| Melissa Martin-Green | Business |
| Steve Pepper | Business |
| Lee Leffler |  |
| Brendon Puffer |  |
| Golden Compass |  |
| Lucas | Business |
| Ryan Callahan | Business |
| Patti Fernandes | Business |
| Lynne Hogan | Business |

## Schedule

| ID | WBS | Task | Type | Duration | Start | Finish | Predecessors | Complete | Baseline start | Baseline finish | Baseline duration | Constraint | Resources | Work | Actual work |
| --- | --- | --- | --- | --- | --- | --- | --- | --- | --- | --- | --- | --- | --- | --- | --- |
| 1 | 1 | **Java Application Touchstone Upgrades** |  | 163d? | 2013-10-21 A | 2014-06-05 A |  | 100% | 2013-10-21 | 2014-06-09 | 166d? |  |  | 1818h | 1818h |
| 2 | 1.1 | **Admissions Applications** |  | 158d | 2013-10-28 A | 2014-06-05 A |  | 100% | 2013-10-28 | 2014-06-09 | 161d |  |  | 938h | 938h |
| 3 | 1.1.1 | **Touchstone Conversion** |  | 158d | 2013-10-28 A | 2014-06-05 A |  | 100% | 2013-10-28 | 2014-04-09 | 118d |  |  | 108h | 108h |
| 4 | 1.1.1.1 | Analysis | manual | 7d | 2013-10-28 A | 2013-11-05 A |  | 100% | 2013-10-28 | 2013-11-05 | 7d |  |  |  |  |
| 5 | 1.1.1.2 | **Development** |  | 123d | 2013-11-06 A | 2014-04-25 A |  | 100% | 2013-11-06 | 2014-04-09 | 111d |  |  | 98h | 98h |
| 6 | 1.1.1.2.1 | **UAQA1 and UAQA2** |  | 104.5d | 2013-11-06 A | 2014-04-01 A |  | 100% | 2013-11-06 | 2014-03-25 | 99.5d |  |  | 54h | 54h |
| 7 | 1.1.1.2.1.1 | Make code changes on UAQ2 | manual | 8d | 2013-11-06 A | 2013-11-15 A | 4 | 100% | 2013-11-06 | 2013-11-15 | 8d |  | Ben Cole [25%] | 14h | 14h |
| 8 | 1.1.1.2.1.2 | Unit test changes on UAQA1 (SSO) | manual | 6d | 2013-11-18 A | 2013-11-25 A | 7 | 100% | 2013-11-18 | 2013-11-22 | 5d |  | Ben Cole [25%] | 12h | 12h |
| 9 | 1.1.1.2.1.3 | Unit test changes on UAQ1 (TS) |  | 14d | 2013-11-18 A | 2014-04-01 A | 8SS | 100% | 2013-11-18 | 2014-03-25 | 10d |  | Ben Cole [25%] | 28h | 28h |
| 10 | 1.1.1.2.2 | **Decisions Servers** |  | 122d | 2013-11-07 A | 2014-04-25 A |  | 100% | 2013-11-07 | 2014-04-09 | 110d |  |  | 44h | 44h |
| 11 | 1.1.1.2.2.1 | Order new servers | manual | 7d | 2013-11-07 A | 2013-11-15 A |  | 100% | 2013-11-07 | 2013-11-15 | 7d |  | Paul Cronin [25%] | 12h | 12h |
| 12 | 1.1.1.2.2.2 | Do trial run of load test cases in old TEST | manual | 5d | 2014-02-10 A | 2014-02-14 A | 11FS+67d | 100% | 2014-02-19 | 2014-02-27 | 7d |  | Ben Cole [25%] | 10h | 10h |
| 13 | 1.1.1.2.2.3 | Configure servers | manual | 4d | 2013-11-18 A | 2013-11-21 A | 11 | 100% | 2013-11-18 | 2013-11-22 | 5d |  | Paul Cronin [25%] | 8h | 8h |
| 14 | 1.1.1.2.2.4 | Test configuration | manual | 1d | 2014-03-24 A | 2014-03-24 A |  | 100% | 2014-03-24 | 2014-03-24 | 1d |  | Paul Cronin [25%] | 2h | 2h |
| 15 | 1.1.1.2.2.5 | Perform load test on new TEST server |  | 4d | 2014-04-22 A | 2014-04-25 A | 9FS+14d | 100% | 2014-01-06 | 2014-01-17 | 10d |  | Paul Cronin [25%] | 8h | 8h |
| 16 | 1.1.1.2.2.6 | Smoke test new TEST server |  | 2d | 2014-04-02 A | 2014-04-03 A | 15 | 100% | 2014-04-08 | 2014-04-09 | 2d |  | Kirsten Derrickson-Boice [25%] | 4h | 4h |
| 17 | 1.1.1.2.3 | Development complete | milestone | 0d | 2014-04-03 A | 2014-04-03 A | 16 | 100% | 2014-01-17 | 2014-01-17 |  |  |  |  |  |
| 18 | 1.1.1.3 | **Go-live** |  | 49.5d | 2014-03-27 A | 2014-06-05 A |  | 100% | 2014-01-23 | 2014-03-24 | 42d |  |  | 10h | 10h |
| 19 | 1.1.1.3.1 | Decisions Servers PROD |  | 1d | 2014-05-05 A | 2014-05-05 A |  | 100% | 2014-01-23 | 2014-01-23 | 1d | start no earlier than 2014-05-05 | Paul Cronin [25%] | 2h | 2h |
| 20 | 1.1.1.3.2 | DEV/UA QA1 | milestone | 0d | 2014-03-27 A | 2014-03-27 A | 9FS-3d | 100% | 2014-03-24 | 2014-03-24 |  | start no earlier than 2014-03-24 | Ben Cole [25%] |  |  |
| 21 | 1.1.1.3.3 | UAT (add entry to StargateReloadable.properties) | milestone | 0d | 2014-05-27 A | 2014-05-27 A |  | 100% |  |  |  | start no earlier than 2014-05-27 | Felicia Leung [25%] |  |  |
| 22 | 1.1.1.3.4 | Smoke test |  | 4d | 2014-05-27 A | 2014-05-30 A | 21 | 100% |  |  |  |  | Kirsten Derrickson-Boice [25%] | 8h | 8h |
| 23 | 1.1.1.3.5 | TEST (add entry to StargateReloadable.properties) | milestone | 0d | 2014-06-04 A | 2014-06-04 A | 20 | 100% | 2014-01-29 | 2014-01-29 | 1d | start no earlier than 2014-06-04 | Felicia Leung [25%] |  |  |
| 24 | 1.1.1.3.6 | PROD (add entry to StargateReloadable.properties) | milestone | 0d | 2014-06-05 A | 2014-06-05 A | 23 | 100% | 2014-01-30 | 2014-01-30 | 1d | start no earlier than 2014-06-05 | Ben Cole [25%] |  |  |
| 25 | 1.1.1.4 | Touchstone Conversion Complete | milestone | 0d | 2014-06-05 A | 2014-06-05 A | 24 | 100% | 2014-01-30 | 2014-01-30 |  |  |  |  |  |

Notes:
- 14: 10 days after Reg Decisions period closes

| ID | WBS | Task | Type | Duration | Start | Finish | Predecessors | Complete | Baseline start | Baseline finish | Baseline duration | Constraint | Resources | Work | Actual work |
| --- | --- | --- | --- | --- | --- | --- | --- | --- | --- | --- | --- | --- | --- | --- | --- |
| 26 | 1.1.2 | **Maven Conversion** |  | 122d | 2013-12-16 A | 2014-06-04 A |  | 100% | 2013-12-16 | 2014-06-09 | 126d |  |  | 830h | 830h |
| 27 | 1.1.2.1 | **Analysis** |  | 50d | 2013-12-16 A | 2014-02-21 A |  | 100% | 2013-12-16 | 2014-01-10 | 20d |  |  | 70h | 70h |
| 28 | 1.1.2.1.1 | Do analysis of UA app suite to see how pieces fit together and what needs to be done to mavenize |  | 35d | 2013-12-16 A | 2014-02-21 A |  | 100% | 2013-12-16 | 2014-01-10 | 16d | start no earlier than 2013-12-16 | Felicia Leung [25%] | 70h | 70h |
| 29 | 1.1.2.2 | **Proof of Concept** |  | 49d | 2014-01-06 A | 2014-03-13 A |  | 100% | 2014-01-13 | 2014-01-27 | 11d |  |  | 94h | 94h |
| 30 | 1.1.2.2.1 | Run Sandbox (branch) experiment to mavenize Stargate-core |  | 21d | 2014-01-06 A | 2014-02-04 A | 28SS+10d | 100% | 2014-01-13 | 2014-01-27 | 11d |  | Felicia Leung [25%] | 42h | 42h |
| 31 | 1.1.2.2.2 | Convert stargate web to Maven |  | 8d | 2014-02-04 A | 2014-02-14 A | 30 | 100% |  |  |  |  | Felicia Leung [25%] | 16h | 16h |
| 32 | 1.1.2.2.3 | Convert stargate ua web to Maven |  | 13d | 2014-02-18 A | 2014-03-06 A | 31 | 100% |  |  |  |  | Felicia Leung [25%] | 26h | 26h |
| 33 | 1.1.2.2.4 | Write tech spec |  | 2d | 2014-03-07 A | 2014-03-10 A | 32 | 100% |  |  |  |  | Felicia Leung [25%] | 4h | 4h |
| 34 | 1.1.2.2.5 | Deploy stargate-core, stargate web, and ua web to maven repository |  | 3d | 2014-03-11 A | 2014-03-13 A | 33 | 100% | 2014-01-13 | 2014-01-27 | 11d |  | Felicia Leung [25%] | 6h | 6h |
| 35 | 1.1.2.3 | **Development** |  | 51d | 2014-03-12 A | 2014-05-21 A |  | 100% | 2014-03-11 | 2014-04-15 | 26d |  |  | 218h | 218h |
| 36 | 1.1.2.3.1 | **Application Maven conversion** |  | 51d | 2014-03-12 A | 2014-05-21 A |  | 100% | 2014-03-11 | 2014-04-15 | 26d |  |  | 218h | 218h |
| 37 | 1.1.2.3.1.1 | Convert and unit test stargate batch web |  | 11d | 2014-03-12 A | 2014-03-26 A | 34SS+1d | 100% | 2014-03-11 | 2014-03-18 | 6d |  | Golden Compass | 88h | 88h |
| 38 | 1.1.2.3.1.2 | Convert and unit test stargate file |  | 5d | 2014-03-27 A | 2014-04-02 A | 37 | 100% | 2014-03-19 | 2014-03-26 | 6d |  | Golden Compass | 40h | 40h |
| 39 | 1.1.2.3.1.3 | Convert and unit test ectrack web |  | 4d | 2014-04-03 A | 2014-04-08 A | 38 | 100% | 2014-03-27 | 2014-04-07 | 8d |  | Golden Compass | 32h | 32h |
| 40 | 1.1.2.3.1.4 | Convert and unit test cpw host |  | 4d | 2014-04-09 A | 2014-04-14 A | 39 | 100% | 2014-04-08 | 2014-04-15 | 6d |  | Golden Compass | 32h | 32h |
| 41 | 1.1.2.3.1.5 | Merge branch with trunk (do code compare between two) |  | 3d | 2014-03-31 A | 2014-04-02 A | 34 | 100% | 2014-04-01 | 2014-04-03 | 3d | start no earlier than 2014-04-01 | Felicia Leung [25%] | 6h | 6h |
| 42 | 1.1.2.3.1.6 | Unit test merged code |  | 2d | 2014-04-03 A | 2014-04-04 A | 41 | 100% | 2014-04-04 | 2014-04-07 | 2d |  | Golden Compass | 16h | 16h |
| 43 | 1.1.2.3.1.7 | Do final merge of branch and trunk in DEV/UAQA1 |  | 2d | 2014-05-20 A | 2014-05-21 A |  | 100% |  |  |  | start no earlier than 2014-05-20 | Ben Cole [25%] | 4h | 4h |
| 44 | 1.1.2.3.1.8 | Development complete | milestone | 0d | 2014-05-21 A | 2014-05-21 A | 43 | 100% | 2014-04-07 | 2014-04-07 |  |  |  |  |  |
| 45 | 1.1.2.4 | **Touchstone and Maven Testing** |  | 55d | 2014-02-26 A | 2014-05-13 A |  | 100% | 2014-03-03 | 2014-06-09 | 71d |  |  | 444h | 444h |
| 46 | 1.1.2.4.1 | **Test Planning** |  | 20d | 2014-02-26 A | 2014-03-25 A |  | 100% | 2014-03-03 | 2014-03-28 | 20d |  |  | 40h | 40h |
| 47 | 1.1.2.4.1.1 | Test Planning |  | 20d | 2014-02-26 A | 2014-03-25 A | 51SS-20d | 100% | 2014-03-03 | 2014-03-28 | 20d |  | Kirsten Derrickson-Boice [25%] | 40h | 40h |
| 48 | 1.1.2.4.2 | **BA Testing** |  | 33.5d | 2014-03-27 A | 2014-05-13 A |  | 100% | 2014-04-01 | 2014-05-12 | 30d |  |  | 232h | 232h |
| 49 | 1.1.2.4.2.1 | Test stargate web |  | 23d | 2014-03-27 A | 2014-05-07 A | 34, 20, 37 | 100% |  |  |  |  | Kirsten Derrickson-Boice [25%] | 46h | 46h |
| 50 | 1.1.2.4.2.2 | Test ua web |  | 23d | 2014-03-27 A | 2014-05-07 A | 49SS | 100% |  |  |  |  | Kirsten Derrickson-Boice [25%] | 46h | 46h |
| 51 | 1.1.2.4.2.3 | Test stargate batch web |  | 23d | 2014-03-27 A | 2014-05-07 A | 49SS | 100% |  |  |  |  | Kirsten Derrickson-Boice [25%] | 46h | 46h |
| 52 | 1.1.2.4.2.4 | Test stargate file |  | 23d | 2014-04-03 A | 2014-05-13 A | 38 | 100% |  |  |  |  | Kirsten Derrickson-Boice [25%] | 46h | 46h |
| 53 | 1.1.2.4.2.5 | Test ecktrackweb |  | 11d | 2014-04-09 A | 2014-05-01 A | 34, 39, 52SS | 100% |  |  |  |  | Kirsten Derrickson-Boice [25%] | 22h | 22h |
| 54 | 1.1.2.4.2.6 | Create cpw host container on uaqa1 |  | 6d | 2014-04-18 A | 2014-04-28 A |  | 100% |  |  |  |  | Paul Cronin [25%] | 12h | 12h |
| 55 | 1.1.2.4.2.7 | Test cpw host |  | 7d | 2014-04-29 A | 2014-05-07 A | 34, 40, 53FF, 54 | 100% |  |  |  |  | Kirsten Derrickson-Boice [25%] | 14h | 14h |
| 56 | 1.1.2.4.2.8 | BA testing complete | milestone | 0d | 2014-05-07 A | 2014-05-07 A | 55 | 100% | 2014-04-01 | 2014-05-12 | 30d |  | Kirsten Derrickson-Boice [25%] |  |  |

Notes:
- 34: setting up bamboo and moves
- 37: talks to stargate web using impersonate function to impersonate education conselor when troubleshooting. is also used stand-alone by ECs
- 41: makes sure builds properly
- 42: test of major functionality of converted apps to make sure working as coded

| ID | WBS | Task | Type | Duration | Start | Finish | Predecessors | Complete | Baseline start | Baseline finish | Baseline duration | Constraint | Resources | Work | Actual work |
| --- | --- | --- | --- | --- | --- | --- | --- | --- | --- | --- | --- | --- | --- | --- | --- |
| 57 | 1.1.2.4.3 | **UAT** |  | 18d | 2014-04-15 A | 2014-05-09 A |  | 100% | 2014-05-13 | 2014-06-06 | 19d |  |  | 172h | 172h |
| 58 | 1.1.2.4.3.1 | Test stargate web (SSO and Touchstone) |  | 17d | 2014-04-15 A | 2014-05-09 A | 49SS+13d | 100% |  |  |  |  | Lynne Hogan [25%] | 34h | 34h |
| 59 | 1.1.2.4.3.2 | Test ua web (SSO and Touchstone) |  | 17d | 2014-04-15 A | 2014-05-09 A | 58SS | 100% |  |  |  |  | Lynne Hogan [25%] | 34h | 34h |
| 60 | 1.1.2.4.3.3 | Test stargate batch web (SSO and Touchstone) |  | 17d | 2014-04-15 A | 2014-05-09 A | 59SS | 100% |  |  |  |  | Lynne Hogan [25%] | 34h | 34h |
| 61 | 1.1.2.4.3.4 | Test stargate file (SSO and Touchstone) |  | 17d | 2014-04-15 A | 2014-05-09 A | 60SS | 100% |  |  |  |  | Lynne Hogan [25%] | 34h | 34h |
| 62 | 1.1.2.4.3.5 | Test ectrack web (SSO and Touchstone) |  | 17d | 2014-04-15 A | 2014-05-09 A | 61SS | 100% |  |  |  |  | Lynne Hogan [25%] | 34h | 34h |
| 63 | 1.1.2.4.3.6 | Test cpw host (SSO and Touchstone) |  | 1d | 2014-05-08 A | 2014-05-09 A | 62FF, 55 | 100% |  |  |  |  | Lynne Hogan [25%] | 2h | 2h |
| 64 | 1.1.2.4.3.7 | UAT complete | milestone | 0d | 2014-05-09 A | 2014-05-09 A | 63 | 100% |  |  |  |  | Lynne Hogan [25%] |  |  |
| 65 | 1.1.2.5 | **Touchstone and Maven Deployment Preparation** |  | 42d | 2014-04-07 A | 2014-06-04 A |  | 100% | 2014-05-20 | 2014-06-06 | 14d |  |  | 4h | 4h |
| 66 | 1.1.2.5.1 | Create deployment plan |  | 1d | 2014-04-07 A | 2014-04-07 A | 64FS-10d | 100% | 2014-05-20 | 2014-06-03 | 10d |  | René Little [25%] | 2h | 2h |
| 67 | 1.1.2.5.2 | Get business approval for deployment |  | 1d | 2014-05-30 A | 2014-05-30 A | 66 | 100% | 2014-06-06 | 2014-06-06 | 1d | start no earlier than 2014-05-30 | René Little [25%] | 2h | 2h |
| 68 | 1.1.2.5.3 | Deployment prepration complete | milestone | 0d | 2014-05-30 A | 2014-05-30 A | 67 | 100% | 2014-06-06 | 2014-06-06 |  |  | René Little [25%] |  |  |
| 69 | 1.1.2.5.4 | Maven PROD Go-live | milestone | 0d | 2014-06-04 A | 2014-06-04 A | 68, 64 | 100% | 2014-06-09 | 2014-06-09 |  | start no earlier than 2014-06-04 |  |  |  |
| 70 | 1.1.2.5.5 | Touchstone and Maven Conversion Complete | milestone | 0d | 2014-06-04 A | 2014-06-04 A | 69 | 100% | 2014-06-09 | 2014-06-09 |  |  |  |  |  |
| 71 | 1.2 | **Moves Touchstone and Tomcat Conversion** |  | 91d | 2013-10-24 A | 2014-02-27 A |  | 100% | 2013-10-24 | 2013-12-06 | 32d |  |  | 132h | 132h |
| 72 | 1.2.1 | **DEV server** |  | 39d | 2013-10-24 A | 2013-12-17 A |  | 100% | 2013-10-24 | 2013-11-19 | 19d |  |  | 72h | 72h |
| 73 | 1.2.1.1 | Set up DEV server | manual | 22d | 2013-10-24 A | 2013-11-22 A |  | 100% | 2013-10-24 | 2013-11-18 | 18d |  | Paul Cronin [25%] | 42h | 42h |
| 74 | 1.2.1.2 | Test DEV server |  | 15d | 2013-11-25 A | 2013-12-17 A | 73 | 100% | 2013-11-19 | 2013-11-19 | 1d |  | Dave Tanner [25%] | 30h | 30h |
| 75 | 1.2.2 | **TEST server** |  | 37d | 2013-11-18 A | 2014-01-07 A |  | 100% | 2013-11-18 | 2013-11-27 | 8d |  |  | 18h | 18h |
| 76 | 1.2.2.1 | Set up TEST server |  | 8d | 2013-11-18 A | 2014-01-06 A | 74 | 100% | 2013-11-18 | 2013-11-26 | 7d |  | Paul Cronin [25%] | 16h | 16h |
| 77 | 1.2.2.2 | Test TEST server |  | 1d | 2014-01-07 A | 2014-01-07 A | 76 | 100% | 2013-11-27 | 2013-11-27 | 1d |  | Steve Turner [25%] | 2h | 2h |
| 78 | 1.2.3 | **PROD server** |  | 74d | 2013-11-18 A | 2014-02-27 A |  | 100% | 2013-12-02 | 2013-12-06 | 5d |  |  | 42h | 42h |
| 79 | 1.2.3.1 | Set up PROD server |  | 16d | 2013-11-18 A | 2013-12-11 A | 76SS | 100% | 2013-12-02 | 2013-12-05 | 4d |  | Paul Cronin [25%] | 32h | 32h |
| 80 | 1.2.3.2 | Finish PROD Server set-up and test |  | 4d | 2014-02-18 A | 2014-02-21 A | 79 | 100% | 2013-12-06 | 2013-12-06 | 1d | start no earlier than 2014-02-18 | Steve Turner [25%] | 8h | 8h |
| 81 | 1.2.3.3 | Cutover PROD server |  | 1d | 2014-02-27 A | 2014-02-27 A | 80FS+2d | 100% |  |  |  |  | Steve Turner [25%] | 2h | 2h |

| ID | WBS | Task | Type | Duration | Start | Finish | Predecessors | Complete | Baseline start | Baseline finish | Baseline duration | Resources | Work | Actual work |
| --- | --- | --- | --- | --- | --- | --- | --- | --- | --- | --- | --- | --- | --- | --- |
| 82 | 1.3 | **MITSIS Upload/Download Touchstone Conversion** |  | 80d | 2013-11-14 A | 2014-03-05 A |  | 100% | 2013-11-14 | 2014-02-18 | 68d? |  | 174h | 174h |
| 83 | 1.3.1 | Document Touchstone upgrades steps | manual | 8d | 2013-11-14 A | 2013-11-25 A |  | 100% | 2013-11-14 | 2013-11-25 | 8d | Steve Turner [25%] | 16h | 16h |
| 84 | 1.3.2 | Set up containers for ALL 5 apps |  | 11d | 2013-11-25 A | 2013-12-11 A |  | 100% | 2013-11-25 | 2013-12-11 | 11d | Paul Cronin [25%] | 22h | 22h |
| 85 | 1.3.3 | **Development** |  | 22d | 2013-12-09 A | 2014-01-07 A |  | 100% | 2013-12-09 | 2014-01-07 | 22d |  | 72h | 72h |
| 86 | 1.3.3.1 | Make Touchstone code changes |  | 6d | 2013-12-09 A | 2013-12-16 A | 83FS+9d | 100% | 2013-12-09 | 2013-12-16 | 6d | Consultant Developer [50%] | 24h | 24h |
| 87 | 1.3.3.2 | Unit test Touchstone code changes |  | 12d | 2013-12-17 A | 2014-01-07 A | 86 | 100% | 2013-12-17 | 2014-01-07 | 12d | Consultant Developer [50%] | 48h | 48h |
| 88 | 1.3.3.3 | Development complete | milestone | 0d | 2014-01-07 A | 2014-01-07 A | 87 | 100% | 2014-01-07 | 2014-01-07 |  | Consultant Developer [50%] |  |  |
| 89 | 1.3.4 | Test Planning | manual | 1d | 2014-01-08 A | 2014-01-08 A | 88 | 100% | 2014-01-08 | 2014-01-08 | 1d | Andrea Collins [25%] | 2h | 2h |
| 90 | 1.3.5 | Set up Bamboo |  | 1d | 2014-01-15 A | 2014-01-15 A |  | 100% | 2014-01-15 | 2014-01-15 | 1d | Steve Turner [25%] | 2h | 2h |
| 91 | 1.3.6 | Configure MOVES |  | 1d | 2014-01-16 A | 2014-01-16 A | 90 | 100% | 2014-01-16 | 2014-01-16 | 1d? | Steve Turner [25%] | 2h | 2h |
| 92 | 1.3.7 | Deploy to test |  | 1d | 2014-01-22 A | 2014-01-22 A | 90 | 100% | 2014-01-16 | 2014-01-16 | 1d? | Steve Turner [25%] | 2h | 2h |
| 93 | 1.3.8 | Do BA testing and bug fixing | manual | 19d | 2014-01-24 A | 2014-02-19 A | 89FS+2d, 88, 92 | 100% | 2014-01-17 | 2014-01-20 | 2d | Andrea Collins [25%] | 36h | 36h |
| 94 | 1.3.9 | Do user testing and bug fixing |  | 7d | 2014-02-20 A | 2014-02-28 A | 93 | 100% | 2014-01-21 | 2014-01-22 | 2d | Brian Canavan [25%] | 14h | 14h |
| 95 | 1.3.10 | Deployment Preparation |  | 2d | 2014-02-19 A | 2014-02-20 A | 93FS-1d | 100% | 2014-01-23 | 2014-01-24 | 2d | René Little [25%] | 4h | 4h |
| 96 | 1.3.11 | Go-live | manual | 1d | 2014-03-05 A | 2014-03-05 A |  | 100% | 2014-02-18 | 2014-02-18 |  | Steve Turner [25%] | 2h | 2h |
| 97 | 1.3.12 | MITSIS Upload/Download Touchstone Conversion Complete | milestone | 0d | 2014-03-05 A | 2014-03-05 A | 96 | 100% | 2014-02-18 | 2014-02-18 |  |  |  |  |
| 98 | 1.4 | **MITSIS ID Assignment Touchstone Conversion** |  | 42d | 2014-01-08 A | 2014-03-06 A |  | 100% | 2014-01-08 | 2014-02-18 | 30d? |  | 56h | 56h |
| 99 | 1.4.1 | **Development** |  | 7d | 2014-01-08 A | 2014-01-16 A |  | 100% | 2014-01-08 | 2014-01-16 | 7d |  | 28h | 28h |
| 100 | 1.4.1.1 | Make Touchstone code changes |  | 3d | 2014-01-08 A | 2014-01-10 A | 88 | 100% | 2014-01-08 | 2014-01-10 | 3d | Consultant Developer [50%] | 12h | 12h |
| 101 | 1.4.1.2 | Unit test Touchstone code changes |  | 4d | 2014-01-13 A | 2014-01-16 A | 100 | 100% | 2014-01-13 | 2014-01-16 | 4d | Consultant Developer [50%] | 16h | 16h |
| 102 | 1.4.1.3 | Development complete | milestone | 0d | 2014-01-16 A | 2014-01-16 A | 101FS-1d | 100% | 2014-01-16 | 2014-01-16 |  | Consultant Developer [50%] |  |  |
| 103 | 1.4.2 | Test Planning |  | 1d | 2014-01-16 A | 2014-01-16 A | 102 | 100% | 2014-01-16 | 2014-01-16 | 1d | Alan Cohen [25%] | 2h | 2h |
| 104 | 1.4.3 | Set up Bamboo |  | 1d | 2014-01-15 A | 2014-01-15 A |  | 100% | 2014-01-15 | 2014-01-15 | 1d | Steve Turner [25%] | 2h | 2h |
| 105 | 1.4.4 | Configure MOVES |  | 1d | 2014-01-16 A | 2014-01-16 A | 104 | 100% | 2014-01-16 | 2014-01-16 | 1d | Steve Turner [25%] | 2h | 2h |
| 106 | 1.4.5 | Deploy to test |  | 1d | 2014-01-17 A | 2014-01-17 A | 105 | 100% | 2014-01-17 | 2014-01-17 | 1d? | Steve Turner [25%] | 2h | 2h |
| 107 | 1.4.6 | Do BA testing and bug fixing |  | 1d | 2014-02-06 A | 2014-02-06 A | 103, 102, 106 | 100% | 2014-01-21 | 2014-01-22 | 2d | Alan Cohen [25%] | 2h | 2h |
| 108 | 1.4.7 | Do user testing and bug fixing |  | 7d | 2014-02-20 A | 2014-02-28 A | 107, 94SS | 100% | 2014-01-23 | 2014-01-24 | 2d | Brian Canavan [25%] | 14h | 14h |
| 109 | 1.4.8 | Deployment Preparation |  | 1d | 2014-02-19 A | 2014-02-19 A | 95SS | 100% | 2014-01-23 | 2014-01-24 | 2d | René Little [25%] | 2h | 2h |
| 110 | 1.4.9 | Go-live | manual | 1d | 2014-03-05 A | 2014-03-05 A | 96SS | 100% | 2014-02-18 | 2014-02-18 |  | Steve Turner [25%] | 2h | 2h |
| 111 | 1.4.10 | MITSIS ID Assignment Touchstone Conversion Complete |  | 1d | 2014-03-06 A | 2014-03-06 A | 110 | 100% | 2014-02-18 | 2014-02-18 | 1d |  |  |  |

| ID | WBS | Task | Type | Duration | Start | Finish | Predecessors | Complete | Baseline start | Baseline finish | Baseline duration | Constraint | Resources | Work | Actual work |
| --- | --- | --- | --- | --- | --- | --- | --- | --- | --- | --- | --- | --- | --- | --- | --- |
| 112 | 1.5 | **Freshmen Folder Touchstone Conversion** |  | 54d | 2014-01-08 A | 2014-03-25 A |  | 100% | 2014-01-08 | 2014-01-24 | 13d? |  |  | 84h | 84h |
| 113 | 1.5.1 | **Development** |  | 5d | 2014-01-08 A | 2014-01-14 A |  | 100% | 2014-01-08 | 2014-01-14 | 5d |  |  | 20h | 20h |
| 114 | 1.5.1.1 | Make Touchstone code changes |  | 2d | 2014-01-08 A | 2014-01-09 A | 100SS | 100% | 2014-01-08 | 2014-01-09 | 2d |  | Consultant Developer [50%] | 8h | 8h |
| 115 | 1.5.1.2 | Unit test Touchstone code changes |  | 3d | 2014-01-09 A | 2014-01-14 A | 114 | 100% | 2014-01-09 | 2014-01-14 | 3d |  | Consultant Developer [50%] | 12h | 12h |
| 116 | 1.5.1.3 | Development complete | milestone | 0d | 2014-01-14 A | 2014-01-14 A | 115 | 100% | 2014-01-14 | 2014-01-14 |  |  | Consultant Developer [50%] |  |  |
| 117 | 1.5.2 | Test Planning |  | 1d | 2014-01-15 A | 2014-01-15 A | 116 | 100% | 2014-01-15 | 2014-01-15 | 1d |  | Jim Frederick [25%] | 2h | 2h |
| 118 | 1.5.3 | Set up Bamboo |  | 1d | 2014-01-15 A | 2014-01-15 A |  | 100% | 2014-01-15 | 2014-01-15 | 1d |  | Steve Turner [25%] | 2h | 2h |
| 119 | 1.5.4 | Configure MOVES |  | 1d | 2014-01-16 A | 2014-01-16 A | 118 | 100% | 2014-01-16 | 2014-01-16 | 1d? |  | Steve Turner [25%] | 2h | 2h |
| 120 | 1.5.5 | Deploy to test |  | 1d | 2014-01-22 A | 2014-01-22 A | 119 | 100% | 2014-01-17 | 2014-01-17 | 1d? |  | Steve Turner [25%] | 2h | 2h |
| 121 | 1.5.6 | Do BA testing and bug fixing |  | 25d | 2014-01-23 A | 2014-02-27 A | 117, 116, 120 | 100% | 2014-01-21 | 2014-01-22 | 2d |  | Jim Frederick [25%] | 50h | 50h |
| 122 | 1.5.7 | Do user testing and bug fixing |  | 2d | 2014-02-28 A | 2014-03-03 A | 121 | 100% | 2014-01-23 | 2014-01-24 | 2d |  | Melissa Martin-Green [25%] | 4h | 4h |
| 123 | 1.5.8 | Deployment Preparation |  | 1d | 2014-03-19 A | 2014-03-19 A | 122 | 100% | 2014-01-21 | 2014-01-22 | 2d |  | René Little [25%] | 2h | 2h |
| 124 | 1.5.9 | Go-live | milestone | 0d | 2014-03-25 A | 2014-03-25 A | 123, 122 | 100% | 2014-01-24 | 2014-01-24 |  | start no earlier than 2014-03-25 | Steve Turner [25%] |  |  |
| 125 | 1.5.10 | Freshmen Folder Touchstone Conversion Complete | milestone | 0d | 2014-03-25 A | 2014-03-25 A | 124 | 100% | 2014-01-24 | 2014-01-24 |  |  |  |  |  |
| 126 | 1.6 | **Test Score Maintenance Touchstone Conversion** |  | 52d | 2014-01-13 A | 2014-03-25 A |  | 100% | 2014-01-13 | 2014-01-29 | 13d? |  |  | 92h | 92h |
| 127 | 1.6.1 | **Development** |  | 8d | 2014-01-13 A | 2014-01-22 A |  | 100% | 2014-01-13 | 2014-01-22 | 8d |  |  | 28h | 28h |
| 128 | 1.6.1.1 | Make Touchstone code changes |  | 3d | 2014-01-13 A | 2014-01-15 A | 114FS+1d | 100% | 2014-01-13 | 2014-01-15 | 3d |  | Consultant Developer [50%] | 12h | 12h |
| 129 | 1.6.1.2 | Unit test Touchstone code changes |  | 4d | 2014-01-16 A | 2014-01-22 A | 128 | 100% | 2014-01-16 | 2014-01-22 | 4d |  | Consultant Developer [50%] | 16h | 16h |
| 130 | 1.6.1.3 | Development complete | milestone | 0d | 2014-01-22 A | 2014-01-22 A | 129 | 100% | 2014-01-22 | 2014-01-22 |  |  | Consultant Developer [50%] |  |  |
| 131 | 1.6.2 | Test Planning | manual | 1d | 2014-01-23 A | 2014-01-23 A | 130 | 100% | 2014-01-23 | 2014-01-23 | 1d |  | Jim Frederick [25%] | 2h | 2h |
| 132 | 1.6.3 | Set up Bamboo |  | 1d | 2014-01-15 A | 2014-01-15 A |  | 100% | 2014-01-15 | 2014-01-15 | 1d? |  | Steve Turner [25%] | 2h | 2h |
| 133 | 1.6.4 | Configure MOVES |  | 1d | 2014-01-16 A | 2014-01-16 A | 132 | 100% | 2014-01-16 | 2014-01-16 | 1d? |  | Steve Turner [25%] | 2h | 2h |
| 134 | 1.6.5 | Deploy to test |  | 1d | 2014-01-22 A | 2014-01-22 A | 133 | 100% | 2014-01-17 | 2014-01-17 | 1d? |  | Steve Turner [25%] | 2h | 2h |
| 135 | 1.6.6 | Do BA testing and bug fixing |  | 20d | 2014-01-23 A | 2014-02-21 A | 131, 130, 134 | 100% | 2014-01-24 | 2014-01-27 | 2d |  | Jim Frederick [25%] | 40h | 40h |
| 136 | 1.6.7 | Do user testing and bug fixing |  | 5d | 2014-02-24 A | 2014-02-28 A | 135 | 100% | 2014-01-28 | 2014-01-29 | 2d |  | Steve Pepper [25%] | 10h | 10h |
| 137 | 1.6.8 | Deployment Preparation |  | 2d | 2014-01-23 A | 2014-01-24 A | 135SS | 100% | 2014-01-24 | 2014-01-27 | 2d |  | René Little [25%] | 4h | 4h |
| 138 | 1.6.9 | Go-live |  | 1d | 2014-03-25 A | 2014-03-25 A | 137, 136 | 100% | 2014-01-29 | 2014-01-29 |  | start no earlier than 2014-03-25 | Steve Turner [25%] | 2h | 2h |
| 139 | 1.6.10 | Test Score Maintenance Touchstone Conversion Complete | milestone | 0d | 2014-03-25 A | 2014-03-25 A | 138 | 100% | 2014-01-29 | 2014-01-29 |  |  |  |  |  |

| ID | WBS | Task | Type | Duration | Start | Finish | Predecessors | Complete | Baseline start | Baseline finish | Baseline duration | Constraint | Resources | Work | Actual work |
| --- | --- | --- | --- | --- | --- | --- | --- | --- | --- | --- | --- | --- | --- | --- | --- |
| 140 | 1.7 | **Provost Funding Source Reporter Touchstone Conversion** |  | 98d? | 2013-10-21 A | 2014-03-05 A |  | 100% | 2013-10-21 | 2014-02-05 | 78d? |  |  | 56h | 56h |
| 141 | 1.7.1 | **Development** |  | 7d | 2014-01-23 A | 2014-01-31 A |  | 100% | 2014-01-23 | 2014-01-31 | 7d |  |  | 28h | 28h |
| 142 | 1.7.1.1 | Make Touchstone code changes |  | 3d | 2014-01-23 A | 2014-01-27 A | 130 | 100% | 2014-01-23 | 2014-01-27 | 3d |  | Consultant Developer [50%] | 12h | 12h |
| 143 | 1.7.1.2 | Unit test Touchstone code changes |  | 4d | 2014-01-28 A | 2014-01-31 A | 142 | 100% | 2014-01-28 | 2014-01-31 | 4d |  | Consultant Developer [50%] | 16h | 16h |
| 144 | 1.7.1.3 | Development complete | milestone | 0d | 2014-01-31 A | 2014-01-31 A | 143 | 100% | 2014-01-31 | 2014-01-31 |  |  | Consultant Developer [50%] |  |  |
| 145 | 1.7.2 | Test Planning |  | 1d | 2014-02-03 A | 2014-02-03 A | 144 | 100% | 2014-02-03 | 2014-02-03 | 1d |  | Kirsten Derrickson-Boice [25%] | 2h | 2h |
| 146 | 1.7.3 | Set up Bamboo |  | 1d | 2013-10-21 A | 2013-10-21 A |  | 100% | 2013-10-21 | 2013-10-21 | 1d |  | Steve Turner [25%] | 2h | 2h |
| 147 | 1.7.4 | Configure MOVES |  | 1d? | 2013-10-22 A | 2013-10-22 A | 146 | 100% | 2013-10-22 | 2013-10-22 | 1d? |  | Steve Turner [25%] | 2h | 2h |
| 148 | 1.7.5 | Deploy to test |  | 1d? | 2013-10-23 A | 2013-10-23 A | 147 | 100% | 2013-10-23 | 2013-10-23 | 1d? |  | Steve Turner [25%] | 2h | 2h |
| 149 | 1.7.6 | Do BA testing and bug fixing |  | 7d | 2014-02-06 A | 2014-02-14 A | 145, 144, 148 | 100% | 2014-02-04 | 2014-02-04 | 1d |  | Kirsten Derrickson-Boice [25%] | 14h | 14h |
| 150 | 1.7.7 | Deployment Preparation |  | 2d | 2014-02-06 A | 2014-02-07 A | 149SS | 100% | 2014-02-04 | 2014-02-05 | 2d |  | René Little [25%] | 4h | 4h |
| 151 | 1.7.8 | Go-live |  | 1d | 2014-03-05 A | 2014-03-05 A | 150 | 100% | 2014-02-05 | 2014-02-05 |  |  | Steve Turner [25%] | 2h | 2h |
| 152 | 1.7.9 | Provost Funding Source Reporter Touchstone Conversion Complete | milestone | 0d | 2014-03-05 A | 2014-03-05 A | 151 | 100% | 2014-02-05 | 2014-02-05 |  |  |  |  |  |
| 153 | 1.8 | **Batch Grade Report Touchstone Conversion** |  | 43d | 2014-01-23 A | 2014-03-25 A |  | 100% | 2014-01-23 | 2014-02-20 | 21d |  |  | 134h | 134h |
| 154 | 1.8.1 | Write functional spec |  | 7d | 2014-01-23 A | 2014-01-31 A |  | 100% | 2014-01-23 | 2014-01-31 | 7d | start no earlier than 2014-01-23 | Steve Turner [25%] | 14h | 14h |
| 155 | 1.8.2 | **Development** |  | 7d | 2014-02-03 A | 2014-02-11 A |  | 100% | 2014-02-03 | 2014-02-11 | 7d |  |  | 56h | 56h |
| 156 | 1.8.2.1 | Make Touchstone code changes |  | 3d | 2014-02-03 A | 2014-02-05 A | 144, 154 | 100% | 2014-02-03 | 2014-02-05 | 3d |  | Consultant Developer | 24h | 24h |
| 157 | 1.8.2.2 | Unit test Touchstone code changes |  | 4d | 2014-02-06 A | 2014-02-11 A | 156 | 100% | 2014-02-06 | 2014-02-11 | 4d |  | Consultant Developer | 32h | 32h |
| 158 | 1.8.2.3 | Development complete | milestone | 0d | 2014-02-11 A | 2014-02-11 A | 157 | 100% | 2014-02-11 | 2014-02-11 |  |  | Consultant Developer |  |  |
| 159 | 1.8.3 | Set up containers for DEV and TEST |  | 1d | 2014-01-31 A | 2014-01-31 A | 156SS | 100% | 2014-02-03 | 2014-02-05 | 3d |  | Paul Cronin [25%] | 2h | 2h |
| 160 | 1.8.4 | Set up Bamboo |  | 1d | 2014-02-18 A | 2014-02-18 A | 159SS+1d | 100% | 2014-02-04 | 2014-02-04 | 1d |  | Steve Turner [25%] | 2h | 2h |
| 161 | 1.8.5 | Configure MOVES |  | 1d | 2014-02-18 A | 2014-02-18 A | 160 | 100% | 2014-02-05 | 2014-02-05 | 1d |  | Steve Turner [25%] | 2h | 2h |
| 162 | 1.8.6 | Deploy to test |  | 1d | 2014-02-18 A | 2014-02-18 A | 161, 158 | 100% | 2014-02-12 | 2014-02-12 | 1d |  | Steve Turner [25%] | 2h | 2h |
| 163 | 1.8.7 | Test Planning |  | 1d | 2014-02-06 A | 2014-02-06 A | 157SS | 100% | 2014-02-06 | 2014-02-06 | 1d |  | Alan Cohen [25%] | 2h | 2h |
| 164 | 1.8.8 | Do BA testing and bug fixing |  | 2d | 2014-02-19 A | 2014-02-20 A | 162, 158, 163 | 100% | 2014-02-13 | 2014-02-14 | 2d |  | Alan Cohen [25%] | 4h | 4h |
| 165 | 1.8.9 | Do user testing and bug fixing |  | 6d | 2014-03-07 A | 2014-03-14 A | 164 | 100% | 2014-02-17 | 2014-02-18 | 2d |  | Brian Canavan | 48h | 48h |
| 166 | 1.8.10 | Deployment Preparation |  | 1d | 2014-03-19 A | 2014-03-19 A | 165 | 100% | 2014-02-19 | 2014-02-20 | 2d |  | René Little [25%] | 2h | 2h |
| 167 | 1.8.11 | Go-live | milestone | 0d | 2014-03-25 A | 2014-03-25 A | 166 | 100% | 2014-02-20 | 2014-02-20 |  | start no earlier than 2014-03-25 | Steve Turner [25%] |  |  |
| 168 | 1.8.12 | Batch Grade Report Touchstone Conversion Complete | milestone | 0d | 2014-03-25 A | 2014-03-25 A | 167 | 100% | 2014-02-20 | 2014-02-20 |  |  |  |  |  |

Notes:
- 166: needs to include setting up PROD container

| ID | WBS | Task | Type | Duration | Start | Finish | Predecessors | Complete | Baseline start | Baseline finish | Baseline duration | Constraint | Resources | Work | Actual work |
| --- | --- | --- | --- | --- | --- | --- | --- | --- | --- | --- | --- | --- | --- | --- | --- |
| 169 | 1.9 | **CAMemail Advisor Email Touchstone Conversion** |  | 24d | 2014-01-31 A | 2014-03-05 A |  | 100% | 2014-02-03 | 2014-02-28 | 20d |  |  | 90h | 90h |
| 170 | 1.9.1 | Write functional spec |  | 5d | 2014-02-03 A | 2014-02-07 A | 154 | 100% | 2014-02-03 | 2014-02-07 | 5d |  | Steve Turner [25%] | 10h | 10h |
| 171 | 1.9.2 | **Development** |  | 8d | 2014-02-12 A | 2014-02-21 A |  | 100% | 2014-02-12 | 2014-02-20 | 7d |  |  | 56h | 56h |
| 172 | 1.9.2.1 | Make Touchstone code changes |  | 3d | 2014-02-12 A | 2014-02-14 A | 158, 170 | 100% | 2014-02-12 | 2014-02-14 | 3d |  | Consultant Developer | 24h | 24h |
| 173 | 1.9.2.2 | Unit test Touchstone code changes |  | 4d | 2014-02-18 A | 2014-02-21 A | 172 | 100% | 2014-02-17 | 2014-02-20 | 4d |  | Consultant Developer | 32h | 32h |
| 174 | 1.9.2.3 | Development complete | milestone | 0d | 2014-02-21 A | 2014-02-21 A | 173 | 100% | 2014-02-20 | 2014-02-20 |  |  | Consultant Developer |  |  |
| 175 | 1.9.3 | Set up containers for DEV and TEST |  | 1d | 2014-01-31 A | 2014-01-31 A | 172SS | 100% | 2014-02-12 | 2014-02-14 | 3d |  | Paul Cronin [25%] | 2h | 2h |
| 176 | 1.9.4 | Set up Bamboo |  | 1d | 2014-02-03 A | 2014-02-03 A | 175SS+1d | 100% | 2014-02-13 | 2014-02-13 | 1d |  | Steve Turner [25%] | 2h | 2h |
| 177 | 1.9.5 | Configure MOVES |  | 1d | 2014-02-04 A | 2014-02-04 A | 176 | 100% | 2014-02-14 | 2014-02-14 | 1d |  | Steve Turner [25%] | 2h | 2h |
| 178 | 1.9.6 | Deploy to test |  | 1d | 2014-02-24 A | 2014-02-24 A | 177, 174 | 100% | 2014-02-21 | 2014-02-21 | 1d |  | Steve Turner [25%] | 2h | 2h |
| 179 | 1.9.7 | Test Planning |  | 1d | 2014-02-18 A | 2014-02-18 A | 173SS | 100% | 2014-02-17 | 2014-02-17 | 1d |  | Lee Leffler [25%] | 2h | 2h |
| 180 | 1.9.8 | Do BA testing and bug fixing |  | 2d | 2014-02-24 A | 2014-02-25 A | 178, 179, 174 | 100% | 2014-02-24 | 2014-02-25 | 2d |  | Lee Leffler [25%] | 4h | 4h |
| 181 | 1.9.9 | Do user testing and bug fixing |  | 1d | 2014-02-26 A | 2014-02-26 A | 180 | 100% | 2014-02-26 | 2014-02-27 | 2d |  | Patti Fernandes | 8h | 8h |
| 182 | 1.9.10 | Deployment Preparation |  | 1d | 2014-02-27 A | 2014-02-27 A | 181 | 100% | 2014-02-28 | 2014-02-28 | 1d |  | René Little [25%] | 2h | 2h |
| 183 | 1.9.11 | Go-live |  | 1d | 2014-03-05 A | 2014-03-05 A | 182 | 100% | 2014-02-28 | 2014-02-28 |  |  |  |  |  |
| 184 | 1.9.12 | CAMemail Advisor Email Touchstone Conversion Complete | milestone | 0d | 2014-03-05 A | 2014-03-05 A | 183 | 100% | 2014-02-28 | 2014-02-28 |  |  |  |  |  |
| 185 | 1.10 | **Federal Work Study Touchstone Conversion** |  | 37d | 2014-01-31 A | 2014-03-25 A |  | 100% | 2014-02-10 | 2014-03-11 | 22d |  |  | 24h | 24h |
| 186 | 1.10.1 | Set up containers for DEV and TEST |  | 1d | 2014-01-31 A | 2014-01-31 A |  | 100% | 2014-02-21 | 2014-02-25 | 3d |  | Paul Cronin [25%] | 2h | 2h |
| 187 | 1.10.2 | Set up Bamboo |  | 1d | 2014-02-03 A | 2014-02-03 A | 186 | 100% | 2014-02-24 | 2014-02-24 | 1d |  | Steve Turner [25%] | 2h | 2h |
| 188 | 1.10.3 | Configure MOVES |  | 1d | 2014-02-04 A | 2014-02-04 A | 187 | 100% | 2014-02-25 | 2014-02-25 | 1d |  | Steve Turner [25%] | 2h | 2h |
| 189 | 1.10.4 | Deploy to test |  | 1d | 2014-02-05 A | 2014-02-05 A | 188 | 100% | 2014-03-04 | 2014-03-04 | 1d |  | Steve Turner [25%] | 2h | 2h |
| 190 | 1.10.5 | Test Planning |  | 1d | 2014-02-06 A | 2014-02-06 A | 189 | 100% | 2014-02-26 | 2014-02-26 | 1d |  | Brendon Puffer [25%] | 2h | 2h |
| 191 | 1.10.6 | Do BA testing and bug fixing |  | 2d | 2014-03-14 A | 2014-03-17 A | 189, 190 | 100% | 2014-03-05 | 2014-03-06 | 2d |  | Brendon Puffer [25%] | 4h | 4h |
| 192 | 1.10.7 | Do user testing and bug fixing |  | 1d | 2014-03-18 A | 2014-03-18 A | 191 | 100% | 2014-03-07 | 2014-03-10 | 2d |  | Ryan Callahan | 8h | 8h |
| 193 | 1.10.8 | Deployment Preparation |  | 1d | 2014-03-19 A | 2014-03-19 A | 192 | 100% | 2014-03-11 | 2014-03-11 | 1d |  | René Little [25%] | 2h | 2h |
| 194 | 1.10.9 | Go-live | milestone | 0d | 2014-03-25 A | 2014-03-25 A | 193 | 100% | 2014-03-11 | 2014-03-11 |  | start no earlier than 2014-03-25 |  |  |  |
| 195 | 1.10.10 | Federal Work Study Touchstone Conversion Complete | milestone | 0d | 2014-03-25 A | 2014-03-25 A | 194 | 100% | 2014-03-11 | 2014-03-11 |  |  |  |  |  |

Notes:
- 182: needs to include setting up PROD container
- 193: needs to include setting up PROD container

| ID | WBS | Task | Type | Duration | Start | Finish | Predecessors | Complete | Baseline start | Baseline finish | Baseline duration | Constraint | Resources | Work | Actual work |
| --- | --- | --- | --- | --- | --- | --- | --- | --- | --- | --- | --- | --- | --- | --- | --- |
| 196 | 1.11 | **Grade20 Touchstone Conversion** |  | 65d | 2014-01-31 A | 2014-05-01 A |  | 100% | 2014-02-18 | 2014-05-13 | 61d |  |  | 38h | 38h |
| 197 | 1.11.1 | Write functional spec |  | 10d | 2014-03-17 A | 2014-03-28 A |  | 100% |  |  |  | start no earlier than 2014-03-17 |  |  |  |
| 198 | 1.11.2 | **Development** |  | 6d | 2014-04-07 A | 2014-04-14 A |  | 100% |  |  |  |  |  |  |  |
| 199 | 1.11.2.1 | Make Touchstone code changes |  | 5d | 2014-04-07 A | 2014-04-11 A | 197FS+5d | 100% |  |  |  |  |  |  |  |
| 200 | 1.11.2.2 | Unit test Touchstone code changes |  | 1d | 2014-04-14 A | 2014-04-14 A | 199 | 100% |  |  |  |  |  |  |  |
| 201 | 1.11.2.3 | Development complete | milestone | 0d | 2014-04-14 A | 2014-04-14 A | 200 | 100% |  |  |  |  |  |  |  |
| 202 | 1.11.3 | Set up containers for DEV and TEST |  | 1d | 2014-01-31 A | 2014-01-31 A |  | 100% | 2014-04-25 | 2014-04-29 | 3d |  | Paul Cronin [25%] | 2h | 2h |
| 203 | 1.11.4 | Set up Bamboo |  | 1d | 2014-04-14 A | 2014-04-14 A | 199 | 100% | 2014-04-28 | 2014-04-28 | 1d |  | Steve Turner [25%] | 2h | 2h |
| 204 | 1.11.5 | Configure MOVES |  | 1d | 2014-04-15 A | 2014-04-15 A | 203 | 100% | 2014-04-29 | 2014-04-29 | 1d |  | Steve Turner [25%] | 2h | 2h |
| 205 | 1.11.6 | Deploy to test |  | 1d | 2014-04-15 A | 2014-04-15 A | 201 | 100% | 2014-05-06 | 2014-05-06 | 1d |  | Steve Turner [25%] | 2h | 2h |
| 206 | 1.11.7 | Test Planning |  | 9d | 2014-04-08 A | 2014-04-18 A | 199SS+1d | 100% | 2014-04-30 | 2014-04-30 | 1d |  | Kirsten Derrickson-Boice [25%] | 18h | 18h |
| 207 | 1.11.8 | Do BA testing and bug fixing |  | 1d | 2014-04-29 A | 2014-04-29 A | 205, 206 | 100% | 2014-05-07 | 2014-05-08 | 2d |  | Kirsten Derrickson-Boice [25%] | 2h | 2h |
| 208 | 1.11.9 | Do user testing and bug fixing |  | 1d | 2014-04-30 A | 2014-04-30 A | 207 | 100% | 2014-05-09 | 2014-05-12 | 2d |  | Lucas | 8h | 8h |
| 209 | 1.11.10 | Deployment Preparation |  | 1d | 2014-04-30 A | 2014-04-30 A | 207 | 100% | 2014-05-13 | 2014-05-13 | 1d |  | René Little [25%] | 2h | 2h |
| 210 | 1.11.11 | Go-live | milestone | 0d | 2014-05-01 A | 2014-05-01 A | 209, 208FS+1d | 100% | 2014-05-13 | 2014-05-13 |  |  |  |  |  |
| 211 | 1.11.12 | Grade20 Touchstone Conversion Complete | milestone | 0d | 2014-05-01 A | 2014-05-01 A | 210 | 100% | 2014-05-13 | 2014-05-13 |  |  |  |  |  |

Notes:
- 209: needs to include setting up PROD container
